Schedule from MS Project, 2004-07-01 to 2004-07-08, costs in $.
None

## Calendars

- Standard: Mon-Fri 08:00-12:00, 13:00-17:00; Sat-Sun off.

## Resources

| Resource | Group | Rate | Notes |
| --- | --- | --- | --- |
| Ben Wilson | Planning | 10 |  |
| Jessica Allen | Planning | 15 |  |
| Adam Smith | Planning | 20 |  |
| Debbie Robers | Engineering | 20 | planning background |
| Sarah Mason | Statistics Staff | 20 | statistician |

## Schedule

| ID | Task | Type | Duration | Start | Finish | Predecessors | Baseline start | Baseline finish | Baseline duration | Total slack | Free slack | Resources | Work | Cost | Baseline cost |
| --- | --- | --- | --- | --- | --- | --- | --- | --- | --- | --- | --- | --- | --- | --- | --- |
| 1 | Identify Intersections |  | 0.54d? | 2004-07-01 | 2004-07-01 |  | 2004-07-01 | 2004-07-01 | 0.54d? | 0d |  | Adam Smith | 4.33h | 86.67 | 86.67 |
| 2 | Review Accident Histories |  | 2d? | 2004-07-01 | 2004-07-05 | 1 | 2004-07-01 | 2004-07-05 | 2d? | 0d |  | Jessica Allen | 16h | 240 | 240 |
| 3 | Perform Vehicle Counts |  | 2d? | 2004-07-01 | 2004-07-05 | 1 | 2004-07-01 | 2004-07-06 | 3d? | 0.17d | 0d | Ben Wilson; Debbie Robers [50%] | 24h | 320 | 240 |
| 4 | Perform Traffic Controls Survey |  | 0.54d? | 2004-07-01 | 2004-07-02 | 1 | 2004-07-01 | 2004-07-02 | 0.54d? | 4.71d |  | Jessica Allen | 4.33h | 65 | 65 |
| 5 | Graph and Compare Accident Histories |  | 2.17d? | 2004-07-05 | 2004-07-07 | 2 | 2004-07-05 | 2004-07-07 | 2.17d? | 0d |  | Adam Smith | 17.33h | 346.67 | 346.67 |
| 6 | Graph and Compare Vehicle Counts |  | 2d? | 2004-07-05 | 2004-07-07 | 3 | 2004-07-06 | 2004-07-09 | 3d? | 0.17d |  | Jessica Allen; Sarah Mason [50%] | 24h | 400 | 360 |
| 7 | Identify Highest Risk Intersection | milestone | 1.08d? | 2004-07-07 | 2004-07-08 | 5, 6 | 2004-07-09 | 2004-07-12 | 1.08d? | 0d |  | Adam Smith | 8.67h | 173.33 | 173.33 |
